# Embedded Operating System Distribution

Schedule from Planner, 2012-02-01 to 2012-04-18.
NJIT CCS Capstone Program

## Calendars

- Full Week: Mon-Sun 00:00-23:59.

## Schedule

| ID | WBS | Task | Type | Duration | Start | Finish | Predecessors | Complete | Constraint | Work |
| --- | --- | --- | --- | --- | --- | --- | --- | --- | --- | --- |
| 1 | 1 | Temporary Bootstrap Builder Setup |  |  | 2012-02-01 | 2012-03-03 |  | 50% |  | 767.99h |
| 2 | 2 | **Package Build Helper Tools** |  |  | 2012-02-01 | 2012-03-04 |  |  |  | 791.99h |
| 3 | 2.1 | Development and Testing of opkhelper |  |  | 2012-02-01 | 2012-03-04 |  | 85% | must start on 2012-02-01 | 791.99h |
| 4 | 2.2 | opkhelper 0.1.0 Release | milestone | 0d | 2012-02-14 | 2012-02-14 |  | 100% | must start on 2012-02-14 |  |
| 5 | 2.3 | opkhelper 0.1.1 Release | milestone | 0d | 2012-02-16 | 2012-02-16 |  | 100% | must start on 2012-02-16 |  |
| 6 | 2.4 | opkhelper 0.2.0 Release | milestone | 0d | 2012-03-04 | 2012-03-04 |  | 75% | must start on 2012-03-04 |  |
| 7 | 3 | **System Software Packaging** |  |  | 2012-02-09 | 2012-04-15 |  |  | must start on 2012-02-09 | 1895.98h |
| 8 | 3.1 | **Toolchain Software Packages** |  |  | 2012-02-29 | 2012-03-13 |  |  |  | 384h |
| 9 | 3.1.1 | GMP |  |  | 2012-02-29 | 2012-02-29 |  |  | start no earlier than 2012-02-29 | 24h |
| 10 | 3.1.2 | MPFR |  |  | 2012-02-29 | 2012-02-29 |  |  | start no earlier than 2012-02-29 | 24h |
| 11 | 3.1.3 | MPC |  |  | 2012-02-29 | 2012-02-29 |  |  | start no earlier than 2012-02-29 | 24h |
| 12 | 3.1.4 | GNU Binutils |  |  | 2012-02-29 | 2012-03-01 |  |  | start no earlier than 2012-02-29 | 48h |
| 13 | 3.1.5 | GCC |  |  | 2012-03-03 | 2012-03-09 | 1, 12, 11, 10, 9 |  | start no earlier than 2012-02-29 | 144h |
| 14 | 3.1.6 | EGLIBC |  |  | 2012-03-09 | 2012-03-13 | 1, 13, 12 |  | start no earlier than 2012-02-29 | 96h |
| 15 | 3.1.7 | GNU Make |  |  | 2012-02-29 | 2012-02-29 |  |  | start no earlier than 2012-02-29 | 24h |
| 16 | 3.2 | **System Software Packages** |  |  | 2012-02-09 | 2012-03-24 |  |  |  | 1391.98h |
| 17 | 3.2.1 | BusyBox |  |  | 2012-02-29 | 2012-03-02 |  |  | start no earlier than 2012-02-29 | 72h |
| 18 | 3.2.2 | Platform Configuration |  |  | 2012-02-09 | 2012-03-21 |  | 40% | must start on 2012-02-09 | 1007.99h |
| 19 | 3.2.3 | Linux |  |  | 2012-02-29 | 2012-03-03 |  |  | start no earlier than 2012-02-29 | 96h |
| 20 | 3.2.4 | Base System Files |  |  | 2012-02-29 | 2012-03-02 |  |  | start no earlier than 2012-02-29 | 72h |
| 21 | 3.2.5 | DAS U-Boot |  |  | 2012-03-18 | 2012-03-24 | 28 |  | start no earlier than 2012-02-29 | 144h |
| 22 | 3.3 | **Package Management Software Packages** |  |  | 2012-02-09 | 2012-04-15 |  |  |  | 120h |
| 23 | 3.3.1 | opkg |  |  | 2012-02-09 | 2012-02-09 |  | 100% | must start on 2012-02-09 | 24h |
| 24 | 3.3.2 | fakeroot |  |  | 2012-02-29 | 2012-02-29 |  |  | start no earlier than 2012-02-29 | 24h |
| 25 | 3.3.3 | opkhelper |  |  | 2012-02-16 | 2012-02-16 |  | 100% | must start on 2012-02-16 | 24h |
| 26 | 3.3.4 | opkhelper Build Flags |  |  | 2012-02-29 | 2012-02-29 |  |  | start no earlier than 2012-02-29 | 24h |
| 27 | 3.3.5 | opkg Web Interface |  |  | 2012-04-14 | 2012-04-15 | 49 |  | start no earlier than 2012-02-29 | 24h |

| ID | WBS | Task | Start | Finish | Predecessors | Complete | Constraint | Work |
| --- | --- | --- | --- | --- | --- | --- | --- | --- |
| 28 | 4 | **Target Hardware Procurement** | 2012-02-05 | 2012-03-18 |  | 62% | must start on 2012-02-05 | 2135.98h |
| 29 | 4.1 | Purchase of Computer | 2012-02-05 | 2012-03-18 |  | 50% | must start on 2012-02-05 | 1031.99h |
| 30 | 4.2 | Purchase of Power Supply | 2012-02-14 | 2012-03-09 |  | 50% | must start on 2012-02-14 | 599.99h |
| 31 | 4.3 | Purchase of Boot Media | 2012-02-14 | 2012-02-16 |  | 100% | must start on 2012-02-14 | 72h |
| 32 | 4.4 | Purchase of Interface Cables | 2012-02-21 | 2012-03-09 |  | 50% | must start on 2012-02-21 | 432h |
| 33 | 5 | **Target Hardware Port** | 2012-03-18 | 2012-04-18 |  |  |  | 1415.98h |
| 34 | 5.1 | Temporary Bootstrap Builder Setup | 2012-03-20 | 2012-03-30 | 28FS+48h |  |  | 240h |
| 35 | 5.2 | Package Building | 2012-03-30 | 2012-04-17 | 34 |  |  | 432h |
| 36 | 5.3 | System Testing | 2012-03-18 | 2012-04-18 | 28 |  |  | 743.99h |
| 37 | 6 | **Example Application Software Packaging** | 2012-02-29 | 2012-03-11 |  |  | start no earlier than 2012-02-29 | 599.99h |
| 38 | 6.1 | MPD | 2012-03-07 | 2012-03-11 | 1, 46, 45, 39 |  |  | 96h |
| 39 | 6.2 | GLib | 2012-03-05 | 2012-03-07 | 1, 43, 42, 41, 40 |  |  | 48h |
| 40 | 6.3 | libffi | 2012-02-29 | 2012-02-29 |  |  | start no earlier than 2012-02-29 | 24h |
| 41 | 6.4 | zlib | 2012-02-29 | 2012-03-01 |  |  | start no earlier than 2012-02-29 | 48h |
| 42 | 6.5 | GNU Gettext | 2012-02-29 | 2012-03-01 |  |  | start no earlier than 2012-02-29 | 48h |
| 43 | 6.6 | DBus | 2012-03-03 | 2012-03-05 | 1, 42, 44 |  |  | 48h |
| 44 | 6.7 | expat | 2012-02-29 | 2012-02-29 |  |  | start no earlier than 2012-02-29 | 24h |
| 45 | 6.8 | Libav | 2012-02-29 | 2012-03-03 |  |  | start no earlier than 2012-02-29 | 96h |
| 46 | 6.9 | ALSA Library | 2012-02-29 | 2012-03-02 |  |  | start no earlier than 2012-02-29 | 72h |
| 47 | 6.10 | ALSA Utilities | 2012-03-02 | 2012-03-06 | 46 |  |  | 96h |
| 48 | 7 | **Package Manager Web Interface** | 2012-03-03 | 2012-04-14 |  |  |  | 1007.99h |
| 49 | 7.1 | Development and Testing of opkg Web Interface | 2012-03-03 | 2012-04-14 | 1 |  | start no earlier than 2012-02-29 | 1007.99h |
